# Organisation d'un colloque scientifique

Schedule from MS Project, 2014-06-16 to 2014-09-12, costs in $.
Préparation d'événement
Versalys

## Calendars

- Standard: Mon-Fri 08:00-12:00, 13:00-17:00; Sat-Sun off. Exceptions (off unless hours are given): 2014-06-24 (Fête de la St-Jean-Baptiste), 2014-07-01 (Fête du Canada), 2014-09-01 (Fête du travail).

## Resources

| Resource | Group | Unit | Rate | Cost per use |
| --- | --- | --- | --- | --- |
| Lucie Dorval | Organisation |  | 28 |  |
| Thomas Dupuis | Rédaction |  | 25 |  |
| Jean Fillion | Organisation |  | 22 |  |
| Pierre Legrand | Responsable |  | 35 |  |
| Éric Martel | Comptabilité |  | 32 |  |
| Sophie Martin | Rédaction |  | 30 |  |
| Marie Plourde | Organisation |  | 32 |  |
| Équipe de nettoyage | Nettoyage |  |  | 1500 |
| Imprimeur | Impression |  |  | 2500 |
| Équipement audiovisuel | Location |  |  | 3000 |
| Tables | Location | Tb de 10 prs | 2 |  |
| Chaises | Location | Unité | 0.2 |  |
| Déjeuner | Repas |  |  |  |

## Schedule

| ID | WBS | Task | Duration | Start | Finish | Predecessors | Total slack | Free slack | Constraint | Deadline | Resources | Work | Cost |
| --- | --- | --- | --- | --- | --- | --- | --- | --- | --- | --- | --- | --- | --- |
| 1 | 1 | **Planification du colloque scientifique** | 49.25d | 2014-06-16 | 2014-08-26 |  | 0d |  |  |  |  | 1024h | 30,056 |
| 2 | 1.1 | **Réunions initiales de planification** | 10d | 2014-06-16 | 2014-06-30 |  | 0d |  |  |  |  | 320h | 9,360 |
| 3 | 1.1.1 | Définition du contenu des conférences | 3d | 2014-06-16 | 2014-06-18 |  | 0d |  |  |  | Jean Fillion; Lucie Dorval; Marie Plourde; Pierre Legrand | 96h | 2,808 |
| 4 | 1.1.2 | Détermination de la date du colloque | 2d | 2014-06-19 | 2014-06-20 | 3 | 0d |  |  |  | Jean Fillion; Lucie Dorval; Marie Plourde; Pierre Legrand | 64h | 1,872 |
| 5 | 1.1.3 | Sélection de l'endroit du colloque | 1w | 2014-06-23 | 2014-06-30 | 4 | 0d |  |  |  | Jean Fillion; Lucie Dorval; Marie Plourde; Pierre Legrand | 160h | 4,680 |
| 6 | 1.2 | **Organisation des activités** | 22.5d | 2014-07-02 | 2014-08-01 | 5FS+2h | 0d |  |  |  |  | 392h | 11,304 |
| 7 | 1.2.1 | Détermination du service de traiteur | 2d | 2014-07-02 | 2014-07-04 |  | 0d |  |  |  | Marie Plourde | 16h | 512 |
| 8 | 1.2.2 | Organisation des activités sociales | 1w | 2014-07-04 | 2014-07-11 | 7SS+2d | 32.75d |  |  |  | Marie Plourde | 40h | 1,280 |
| 9 | 1.2.3 | Recherche des conférenciers | 2w | 2014-07-02 | 2014-07-16 | 7SS | 0d |  |  |  | Jean Fillion | 80h | 1,760 |
| 10 | 1.2.4 | Planification de l'horaire du colloque | 2d | 2014-07-16 | 2014-07-18 | 9 | 0d |  |  | 2014-07-18 | Jean Fillion | 16h | 352 |
| 11 | 1.2.5 | Rédaction et impression du programme | 2w | 2014-07-18 | 2014-08-01 | 10 | 1d | 0d |  |  | Sophie Martin; Thomas Dupuis; Imprimeur | 240h | 7,400 |
| 12 | 1.3 | **Relations publiques** | 16.25d | 2014-08-01 | 2014-08-25 | 2, 11 | 1d | 0d |  |  |  | 208h | 6,240 |
| 13 | 1.3.1 | Envoi des invitations | 1d | 2014-08-01 | 2014-08-04 |  | 1d | 0d |  |  | Sophie Martin | 8h | 240 |
| 14 | 1.3.2 | Annonce à la communauté scientifique | 2w | 2014-08-04 | 2014-08-18 | 13 | 1d | 0d |  |  | Thomas Dupuis; Pierre Legrand | 160h | 4,800 |
| 15 | 1.3.3 | Suivi des inscriptions | 1w | 2014-08-19 | 2014-08-25 | 14 | 1d |  |  |  | Sophie Martin | 40h | 1,200 |
| 16 | 1.4 | **Location du personnel et du matériel** | 16d | 2014-08-01 | 2014-08-25 | 12SS | 1.25d |  |  |  |  | 48h | 1,344 |
| 17 | 1.4.1 | Réservation de l'équipe de nettoyage | 1d | 2014-08-01 | 2014-08-18 |  | 1.25d | 0d |  |  | Lucie Dorval | 8h | 224 |
| 18 | 1.4.2 | Location de l'équipement audiovisuel | 3d | 2014-08-18 | 2014-08-21 | 17 | 1.25d | 0d |  |  | Lucie Dorval | 24h | 672 |
| 19 | 1.4.3 | Location des tables et des chaises | 2d | 2014-08-21 | 2014-08-25 | 18 | 1.25d |  |  |  | Lucie Dorval | 16h | 448 |
| 20 | 1.5 | **Réunions, suivi du projet** | 39.25d | 2014-07-02 | 2014-08-26 |  | 0.75d |  |  |  |  | 56h | 1,808 |
| 21 | 1.5.1 | Réunions, suivi du projet 1 | 2h | 2014-07-02 | 2014-07-02 |  | 39.75d |  | start no earlier than 2014-07-01 |  | Déjeuner [0.1%]; Jean Fillion; Marie Plourde; Pierre Legrand; Sophie Martin; Thomas Dupuis | 10h | 328 |
| 22 | 1.5.2 | Réunions, suivi du projet 2 | 2h | 2014-07-15 | 2014-07-15 |  | 30.75d |  | start no earlier than 2014-07-15 |  | Déjeuner [0.1%]; Jean Fillion; Marie Plourde; Pierre Legrand; Sophie Martin; Thomas Dupuis; Lucie Dorval | 12h | 384 |
| 23 | 1.5.3 | Réunions, suivi du projet 3 | 2h | 2014-07-29 | 2014-07-29 |  | 20.75d |  | start no earlier than 2014-07-29 |  | Déjeuner [0.1%]; Jean Fillion; Marie Plourde; Pierre Legrand; Sophie Martin; Thomas Dupuis; Lucie Dorval | 12h | 384 |
| 24 | 1.5.4 | Réunions, suivi du projet 4 | 2h | 2014-08-12 | 2014-08-12 |  | 10.75d |  | start no earlier than 2014-08-12 |  | Déjeuner [0.1%]; Jean Fillion; Marie Plourde; Pierre Legrand; Sophie Martin; Thomas Dupuis | 10h | 328 |
| 25 | 1.5.5 | Réunions, suivi du projet 5 | 2h | 2014-08-26 | 2014-08-26 |  | 0.75d |  | start no earlier than 2014-08-26 |  | Déjeuner [0.1%]; Jean Fillion; Marie Plourde; Pierre Legrand; Sophie Martin; Thomas Dupuis; Lucie Dorval | 12h | 384 |

| ID | WBS | Task | Type | Duration | Start | Finish | Predecessors | Total slack | Free slack | Constraint | Resources | Work | Cost |
| --- | --- | --- | --- | --- | --- | --- | --- | --- | --- | --- | --- | --- | --- |
| 26 | 2 | **Préparation du colloque scientifique** |  | 7.75d | 2014-08-26 | 2014-09-05 | 1 | 0d |  |  |  | 104h | 8,904 |
| 27 | 2.1 | Installation de l'équipement |  | 2d | 2014-08-26 | 2014-08-28 |  | 0.75d | 0d |  | Lucie Dorval | 16h | 448 |
| 28 | 2.2 | Décoration des salles |  | 2d | 2014-08-28 | 2014-09-02 | 27 | 0.75d |  |  | Lucie Dorval | 16h | 448 |
| 29 | 2.3 | Colloque scientifique |  | 3d | 2014-09-03 | 2014-09-05 | 28 | 0d |  | must start on 2014-09-03 | Marie Plourde; Pierre Legrand; Équipement audiovisuel; Chaises [1000 Unité]; Tables [100 Tb de 10 prs] | 72h | 8,008 |
| 30 | 3 | **Clôture du colloque scientifique** |  | 5d | 2014-09-06 | 2014-09-12 | 26 | 0d |  |  |  | 104h | 6,412 |
| 31 | 3.1 | Nettoyage |  | 2d | 2014-09-06 | 2014-09-07 |  | 0d |  |  | Équipe de nettoyage [300%] | 48h | 4,500 |
| 32 | 3.2 | Paiement des factures |  | 2d | 2014-09-08 | 2014-09-09 | 31 | 0d |  |  | Pierre Legrand; Éric Martel | 32h | 1,072 |
| 33 | 3.3 | Envoi des lettres de remerciement |  | 2d | 2014-09-10 | 2014-09-11 | 32 | 0d |  |  | Pierre Legrand | 16h | 560 |
| 34 | 3.4 | Écriture du compte rendu |  | 1d | 2014-09-12 | 2014-09-12 | 33 | 0d |  |  | Pierre Legrand | 8h | 280 |
| 35 | 3.5 | Fin du projet | milestone | 0d | 2014-09-12 | 2014-09-12 | 34 | 0d |  |  |  |  |  |
