# Organisation d'un colloque scientifique

Schedule from MS Project, 2014-06-16 to 2014-09-16.
Préparation d'événement
Versalys

## Calendars

- Standard: Mon-Fri 08:00-12:00, 13:00-17:00; Sat-Sun off. Exceptions (off unless hours are given): 2014-06-24 (Fête de la St-Jean-Baptiste), 2014-07-01 (Fête du Canada), 2014-09-01 (Fête du travail).

## Schedule

| ID | WBS | Task | Duration | Start | Finish | Predecessors | Total slack | Free slack | Constraint |
| --- | --- | --- | --- | --- | --- | --- | --- | --- | --- |
| 1 | 1 | **Planification du colloque scientifique** | 49.25d | 2014-06-16 | 2014-08-26 |  | 0d |  |  |
| 2 | 1.1 | **Réunions initiales de planification** | 10d | 2014-06-16 | 2014-06-30 |  | 1.25d |  |  |
| 3 | 1.1.1 | Définition du contenu des conférences | 3d | 2014-06-16 | 2014-06-18 |  | 1.25d | 0d |  |
| 4 | 1.1.2 | Détermination de la date du colloque | 2d | 2014-06-19 | 2014-06-20 | 3 | 1.25d | 0d |  |
| 5 | 1.1.3 | Sélection de l'endroit du colloque | 1w | 2014-06-23 | 2014-06-30 | 4 | 1.25d | 0d |  |
| 6 | 1.2 | **Organisation des activités** | 22d | 2014-07-02 | 2014-07-31 | 5 | 1.25d |  |  |
| 7 | 1.2.1 | Détermination du service de traiteur | 2d | 2014-07-02 | 2014-07-03 |  | 1.25d | 0d |  |
| 8 | 1.2.2 | Organisation des activités sociales | 1w | 2014-07-02 | 2014-07-08 | 7SS | 1.25d | 0d |  |
| 9 | 1.2.3 | Recherche des conférenciers | 2w | 2014-07-02 | 2014-07-15 | 8SS | 1.25d | 0d |  |
| 10 | 1.2.4 | Planification de l'horaire du colloque | 2d | 2014-07-16 | 2014-07-17 | 9 | 1.25d | 0d |  |
| 11 | 1.2.5 | Rédaction et impression du programme | 2w | 2014-07-18 | 2014-07-31 | 10 | 1.25d | 0d |  |
| 12 | 1.3 | **Relations publiques** | 16d | 2014-08-01 | 2014-08-22 | 2, 11 | 1.25d | 0d |  |
| 13 | 1.3.1 | Envoi des invitations | 1d | 2014-08-01 | 2014-08-01 |  | 1.25d | 0d |  |
| 14 | 1.3.2 | Annonce à la communauté scientifique | 2w | 2014-08-04 | 2014-08-15 | 13 | 1.25d | 0d |  |
| 15 | 1.3.3 | Suivi des inscriptions | 1w | 2014-08-18 | 2014-08-22 | 14 | 1.25d |  |  |
| 16 | 1.4 | **Location du personnel et du matériel** | 6d | 2014-08-01 | 2014-08-08 | 12SS | 11.25d |  |  |
| 17 | 1.4.1 | Réservation de l'équipe de nettoyage | 1d | 2014-08-01 | 2014-08-01 |  | 11.25d | 0d |  |
| 18 | 1.4.2 | Location de l'équipement audiovisuel | 3d | 2014-08-04 | 2014-08-06 | 17 | 11.25d | 0d |  |
| 19 | 1.4.3 | Location des tables et des chaises | 2d | 2014-08-07 | 2014-08-08 | 18 | 11.25d |  |  |
| 20 | 1.5 | **Réunions, suivi du projet** | 39.25d | 2014-07-02 | 2014-08-26 |  | 0d |  |  |
| 21 | 1.5.1 | Réunions, suivi du projet 1 | 2h | 2014-07-02 | 2014-07-02 |  | 50.75d |  | start no earlier than 2014-07-01 |
| 22 | 1.5.2 | Réunions, suivi du projet 2 | 2h | 2014-07-15 | 2014-07-15 |  | 41.75d |  | start no earlier than 2014-07-15 |
| 23 | 1.5.3 | Réunions, suivi du projet 3 | 2h | 2014-07-29 | 2014-07-29 |  | 31.75d |  | start no earlier than 2014-07-29 |
| 24 | 1.5.4 | Réunions, suivi du projet 4 | 2h | 2014-08-12 | 2014-08-12 |  | 21.75d |  | start no earlier than 2014-08-12 |
| 25 | 1.5.5 | Réunions, suivi du projet 5 | 2h | 2014-08-26 | 2014-08-26 |  | 0d |  | start no earlier than 2014-08-26 |

| ID | WBS | Task | Type | Duration | Start | Finish | Predecessors | Total slack |
| --- | --- | --- | --- | --- | --- | --- | --- | --- |
| 26 | 2 | **Préparation du colloque scientifique** |  | 7d | 2014-08-26 | 2014-09-05 | 1 | 0d |
| 27 | 2.1 | Installation de l'équipement |  | 2d | 2014-08-26 | 2014-08-28 |  | 0d |
| 28 | 2.2 | Décoration des salles |  | 2d | 2014-08-28 | 2014-09-02 | 27 | 0d |
| 29 | 2.3 | Colloque scientifique |  | 3d | 2014-09-02 | 2014-09-05 | 28 | 0d |
| 30 | 3 | **Clôture du colloque scientifique** |  | 7d | 2014-09-05 | 2014-09-16 | 26 | 0d |
| 31 | 3.1 | Nettoyage |  | 2d | 2014-09-05 | 2014-09-09 |  | 0d |
| 32 | 3.2 | Paiement des factures |  | 2d | 2014-09-09 | 2014-09-11 | 31 | 0d |
| 33 | 3.3 | Envoi des lettres de remerciement |  | 2d | 2014-09-11 | 2014-09-15 | 32 | 0d |
| 34 | 3.4 | Écriture du compte rendu |  | 1d | 2014-09-15 | 2014-09-16 | 33 | 0d |
| 35 | 3.5 | Fin du projet | milestone | 0d | 2014-09-16 | 2014-09-16 | 34 | 0d |
